# Desarrollo MyWaySoftware 25

Schedule from MS Project, 2015-05-04 to 2015-08-13, status date 2015-05-01, costs in $, A marks actual dates.

## Calendars

- Standard: Mon-Fri 08:00-12:00, 13:00-17:00; Sat-Sun off.

## Resources

| Resource | Group | Rate |
| --- | --- | --- |
| Andrés Cerdas | Dev | 50 |
| Jesé Molina | Dev | 50 |
| Carmen Rojas | PMO | 50 |
| Roberto Campos | Test | 50 |
| Analista de Pruebas | Test | 50 |

## Schedule

| ID | WBS | Task | Type | Duration | Start | Finish | Predecessors | Complete | Remaining | Baseline start | Baseline finish | Baseline duration | Total slack | Free slack | Constraint | Deadline | Resources | Work | Actual work | Cost | Baseline cost | Actual cost |
| --- | --- | --- | --- | --- | --- | --- | --- | --- | --- | --- | --- | --- | --- | --- | --- | --- | --- | --- | --- | --- | --- | --- |
| 1 | 1 | **Análisis de Requerimientos** |  | 14d | 2015-05-04 A | 2015-05-21 A |  | 100% |  | 2012-05-02 | 2012-05-23 | 15.75d |  |  |  |  |  | 66h | 66h | 3,300 | 3,300 | 3,300 |
| 2 | 1.1 | Realizar Análisis de Requerimientos |  | 4d | 2015-05-04 A | 2015-05-07 A |  | 100% |  | 2012-05-02 | 2012-05-07 | 4d |  |  | finish no later than 2015-05-08 |  | Carmen Rojas [75%] | 24h | 24h | 1,200 | 1,200 | 1,200 |
| 3 | 1.2 | Realizar Especificaciones del Software |  | 6d | 2015-05-08 A | 2015-05-15 A | 2 | 100% |  | 2012-05-08 | 2012-05-15 | 6d |  |  |  |  | Andrés Cerdas [62.5%] | 24h | 24h | 1,200 | 1,200 | 1,200 |
| 4 | 1.3 | Desarrollar Presupuesto |  | 1.8d | 2015-05-18 A | 2015-05-19 A | 3 | 100% |  | 2012-05-16 | 2012-05-17 | 1.8d |  |  |  |  | Carmen Rojas [75%] | 10h | 10h | 500 | 500 | 500 |
| 5 | 1.4 | Realizar Cronograma de Desarrollo |  | 3d | 2015-05-18 A | 2015-05-21 A | 4 | 100% |  | 2012-05-18 | 2012-05-23 | 3d |  |  |  |  | Andrés Cerdas [50%] | 8h | 8h | 400 | 400 | 400 |
| 6 | 2 | Fin Proceso de Análisis | milestone | 0d | 2015-05-25 A | 2015-05-25 A | 5 | 100% |  | 2012-05-23 | 2012-05-23 | 0d |  |  |  | 2015-05-25 |  |  |  |  |  |  |
| 7 | 3 | **Diseño** |  | 13d | 2015-05-25 A | 2015-06-10 A |  | 100% |  | 2012-05-24 | 2012-06-11 | 11.75d |  |  |  |  |  | 69h | 69h | 3,650 | 3,650 | 3,650 |
| 8 | 3.1 | Desarrollar Especificaciones Funcionales |  | 9d | 2015-05-25 A | 2015-06-05 A | 6 | 100% |  | 2012-05-24 | 2012-06-07 | 9d |  |  | start no earlier than 2015-05-17 |  | Jesé Molina [62.5%] | 37h | 37h | 1,850 | 1,850 | 1,850 |
| 9 | 3.2 | Desarrollar Prototipo |  | 3d | 2015-06-08 A | 2015-06-10 A | 8 | 100% |  | 2012-06-07 | 2012-06-11 | 3d |  |  |  |  | Jesé Molina | 32h | 32h | 1,800 | 1,800 | 1,800 |
| 10 | 4 | Fin Proceso de Diseño | milestone | 0d | 2015-06-09 A | 2015-06-09 A | 9 | 100% |  | 2012-06-09 | 2012-06-09 | 0d |  |  |  | 2015-06-09 |  |  |  |  |  |  |
| 11 | 5 | **Desarrollo** |  | 25d | 2015-06-10 A | 2015-07-14 |  | 18% | 20.45d | 2012-06-10 | 2012-07-16 | 24.75d | 21d |  |  |  |  | 248h | 32h | 12,400 | 12,400 | 1,600 |
| 12 | 5.1 | Identificar Parámetros de Diseño |  | 1d | 2015-06-10 A | 2015-06-10 A | 10 | 100% |  | 2012-06-10 | 2012-06-11 | 1d |  |  |  |  | Jesé Molina [50%] | 4h | 4h | 200 | 200 | 200 |
| 13 | 5.2 | Desarrollar Programación |  | 21d | 2015-06-15 A | 2015-07-13 | 12 | 14% | 18d | 2012-06-13 | 2012-07-12 | 21d | 22d | 0d |  |  | Jesé Molina | 156h | 12h | 7,800 | 7,800 | 600 |
| 14 | 5.3 | Realizar Pruebas del Software - Programador |  | 22d | 2015-06-15 A | 2015-07-14 | 13SS+1d | 18% | 18d | 2012-06-14 | 2012-07-16 | 21.75d | 3d | 0d |  |  | Analista de Pruebas [50%] | 88h | 16h | 4,400 | 4,400 | 800 |
| 15 | 6 | Fin Proceso de Desarrollo | milestone | 0d | 2015-07-14 | 2015-07-14 | 14 |  |  | 2012-07-16 | 2012-07-16 | 0d | 3d | 0d |  | 2015-07-20 |  |  |  |  |  |  |
| 16 | 7 | **Pruebas** |  | 17d | 2015-07-15 | 2015-08-06 |  |  |  | 2012-07-16 | 2012-08-08 | 17d | 4d |  |  |  |  | 116h |  | 5,800 | 5,800 |  |
| 17 | 7.1 | Realizar Pruebas por Módulos |  | 5d | 2015-07-15 | 2015-07-21 | 15 |  |  | 2012-07-16 | 2012-07-23 | 5d | 4d | 0d | start no earlier than 2015-07-11 |  | Roberto Campos | 40h |  | 2,000 | 2,000 |  |
| 18 | 7.2 | Realizar Pruebas Integrales |  | 2d | 2015-07-22 | 2015-07-23 | 17 |  |  | 2012-07-23 | 2012-07-25 | 2d | 4d | 0d |  |  | Analista de Pruebas | 16h |  | 800 | 800 |  |
| 19 | 7.3 | Identificar Anomalías a las Especificaciones del Software |  | 3d | 2015-07-24 | 2015-07-28 | 18 |  |  | 2012-07-25 | 2012-07-30 | 3d | 4d | 0d |  |  | Analista de Pruebas | 24h |  | 1,200 | 1,200 |  |
| 20 | 7.4 | Realizar Ajustes |  | 5d | 2015-07-29 | 2015-08-04 | 19 |  |  | 2012-07-30 | 2012-08-06 | 5d | 4d | 0d |  |  | Jesé Molina [50%] | 20h |  | 1,000 | 1,000 |  |
| 21 | 7.5 | Realizar Pruebas a Ajustes Realizados |  | 2d | 2015-08-05 | 2015-08-06 | 20 |  |  | 2012-08-06 | 2012-08-08 | 2d | 4d |  |  |  | Roberto Campos | 16h |  | 800 | 800 |  |
| 22 | 8 | Fin Proceso de Pruebas | milestone | 0d | 2015-08-13 | 2015-08-13 | 21 |  |  | 2012-08-12 | 2012-08-12 | 0d | 0d |  | must finish on 2015-08-13 |  |  |  |  |  |  |  |
