# Desarrollo MyWaySoftware 30

Schedule from MS Project, 2015-06-03 to 2015-09-14, status date 2015-05-31, costs in $, A marks actual dates.

## Calendars

- Proyectos MyWay: Mon-Fri 08:00-12:00, 13:00-17:00; Sat-Sun off.

## Resources

| Resource | Group | Rate |
| --- | --- | --- |
| Andrés Cerdas | Dev | 50 |
| Jesé Molina | Dev | 50 |
| Carmen Rojas | PMO | 50 |
| Roberto Campos | Test | 50 |
| Analista de Pruebas | Test | 50 |

## Schedule

| ID | WBS | Task | Type | Duration | Start | Finish | Predecessors | Complete | Remaining | Baseline start | Baseline finish | Baseline duration | Baseline 1 start | Baseline 1 finish | Total slack | Free slack | Constraint | Deadline | Resources | Work | Actual work | Cost | Baseline cost | Actual cost |
| --- | --- | --- | --- | --- | --- | --- | --- | --- | --- | --- | --- | --- | --- | --- | --- | --- | --- | --- | --- | --- | --- | --- | --- | --- |
| 1 | 1 | **Análisis de Requerimientos** |  | 14d | 2015-06-03 A | 2015-06-22 A |  | 100% |  | 2015-05-04 | 2015-05-21 | 14d | 2015-05-04 | 2015-05-21 |  |  |  |  |  | 66h | 66h | 3,300 | 3,300 | 3,300 |
| 2 | 1.1 | Realizar Análisis de Requerimientos |  | 4d | 2015-06-03 A | 2015-06-08 A |  | 100% |  | 2015-05-04 | 2015-05-07 | 4d | 2015-05-04 | 2015-05-07 |  |  | finish no later than 2015-06-07 |  | Carmen Rojas [75%] | 24h | 24h | 1,200 | 1,200 | 1,200 |
| 3 | 1.2 | Realizar Especificaciones del Software |  | 6d | 2015-06-08 A | 2015-06-15 A | 2 | 100% |  | 2015-05-08 | 2015-05-15 | 6d | 2015-05-08 | 2015-05-15 |  |  |  |  | Andrés Cerdas [62.5%] | 24h | 24h | 1,200 | 1,200 | 1,200 |
| 4 | 1.3 | Desarrollar Presupuesto |  | 1.8d | 2015-06-17 A | 2015-06-18 A | 3 | 100% |  | 2015-05-18 | 2015-05-19 | 1.8d | 2015-05-18 | 2015-05-19 |  |  |  |  | Carmen Rojas [75%] | 10h | 10h | 500 | 500 | 500 |
| 5 | 1.4 | Realizar Cronograma de Desarrollo |  | 3d | 2015-06-17 A | 2015-06-22 A | 4 | 100% |  | 2015-05-18 | 2015-05-21 | 3d | 2015-05-18 | 2015-05-21 |  |  |  |  | Andrés Cerdas [50%] | 8h | 8h | 400 | 400 | 400 |
| 6 | 2 | Fin Proceso de Análisis | milestone | 0d | 2015-06-24 A | 2015-06-24 A | 5 | 100% |  | 2015-05-25 | 2015-05-25 | 0d | 2015-05-25 | 2015-05-25 |  |  |  | 2015-06-24 |  |  |  |  |  |  |
| 7 | 3 | **Diseño** |  | 15d | 2015-06-24 A | 2015-07-14 A |  | 100% |  | 2015-05-25 | 2015-06-10 | 13d | 2015-05-25 | 2015-06-10 |  |  |  |  |  | 74h | 74h | 3,700 | 3,650 | 3,700 |
| 8 | 3.1 | Desarrollar Especificaciones Funcionales |  | 10d | 2015-06-24 A | 2015-07-08 A | 6 | 100% |  | 2015-05-25 | 2015-06-05 | 9d | 2015-05-25 | 2015-06-05 |  |  | start no earlier than 2015-06-16 |  | Jesé Molina [62.5%] | 42h | 42h | 2,100 | 1,850 | 2,100 |
| 9 | 3.2 | Desarrollar Prototipo |  | 4d | 2015-07-09 A | 2015-07-14 A | 8 | 100% |  | 2015-06-08 | 2015-06-10 | 3d | 2015-06-08 | 2015-06-10 |  |  |  |  | Jesé Molina | 32h | 32h | 1,600 | 1,800 | 1,600 |
| 10 | 4 | Fin Proceso de Diseño | milestone | 0d | 2015-07-14 A | 2015-07-14 A | 9 | 100% |  | 2015-06-09 | 2015-06-09 | 0d | 2015-06-09 | 2015-06-09 |  |  |  |  |  |  |  |  |  |  |
| 11 | 5 | **Desarrollo** |  | 23d | 2015-07-16 A | 2015-08-17 |  | 19% | 18.6d | 2015-06-10 | 2015-07-14 | 25d | 2015-06-10 | 2015-07-14 | 19d |  |  |  |  | 264h | 36h | 13,200 | 12,400 | 1,800 |
| 12 | 5.1 | Identificar Parámetros de Diseño |  | 2d | 2015-07-16 A | 2015-07-17 A | 10 | 100% |  | 2015-06-10 | 2015-06-10 | 1d | 2015-06-10 | 2015-06-10 |  |  |  |  | Jesé Molina [50%] | 8h | 8h | 400 | 200 | 400 |
| 13 | 5.2 | Desarrollar Programación |  | 22d | 2015-07-16 A | 2015-08-14 | 12 | 14% | 19d | 2015-06-15 | 2015-07-13 | 21d | 2015-06-15 | 2015-07-13 | 20d | 0d |  |  | Jesé Molina | 164h | 12h | 8,200 | 7,800 | 600 |
| 14 | 5.3 | Realizar Pruebas del Software - Programador |  | 23d | 2015-07-16 A | 2015-08-17 | 13SS+1d | 17% | 19d | 2015-06-15 | 2015-07-14 | 22d | 2015-06-15 | 2015-07-14 | 0d |  |  |  | Analista de Pruebas [50%] | 92h | 16h | 4,600 | 4,400 | 800 |
| 15 | 6 | Fin Proceso de Desarrollo | milestone | 0d | 2015-08-17 | 2015-08-17 | 14 |  |  | 2015-07-14 | 2015-07-14 | 0d | 2015-07-14 | 2015-07-14 | 0d |  |  | 2015-08-19 |  |  |  |  |  |  |
| 16 | 7 | **Pruebas** |  | 19d | 2015-08-18 | 2015-09-11 |  |  |  | 2015-07-15 | 2015-08-06 | 17d | 2015-07-15 | 2015-08-06 | 0d |  |  |  |  | 132h |  | 6,600 | 5,800 |  |
| 17 | 7.1 | Realizar Pruebas por Módulos |  | 6d | 2015-08-18 | 2015-08-25 | 15 |  |  | 2015-07-15 | 2015-07-21 | 5d | 2015-07-15 | 2015-07-21 | 0d |  | start no earlier than 2015-08-10 |  | Roberto Campos | 48h |  | 2,400 | 2,000 |  |
| 18 | 7.2 | Realizar Pruebas Integrales |  | 2d | 2015-08-26 | 2015-08-27 | 17 |  |  | 2015-07-22 | 2015-07-23 | 2d | 2015-07-22 | 2015-07-23 | 0d |  |  |  | Analista de Pruebas | 16h |  | 800 | 800 |  |
| 19 | 7.3 | Identificar Anomalías a las Especificaciones del Software |  | 3d | 2015-08-28 | 2015-09-01 | 18 |  |  | 2015-07-24 | 2015-07-28 | 3d | 2015-07-24 | 2015-07-28 | 0d |  |  |  | Analista de Pruebas | 24h |  | 1,200 | 1,200 |  |
| 20 | 7.4 | Realizar Ajustes |  | 5d | 2015-09-02 | 2015-09-08 | 19 |  |  | 2015-07-29 | 2015-08-04 | 5d | 2015-07-29 | 2015-08-04 | 0d |  |  |  | Jesé Molina [50%] | 20h |  | 1,000 | 1,000 |  |
| 21 | 7.5 | Realizar Pruebas a Ajustes Realizados |  | 3d | 2015-09-09 | 2015-09-11 | 20 |  |  | 2015-08-05 | 2015-08-06 | 2d | 2015-08-05 | 2015-08-06 | 0d |  |  |  | Roberto Campos | 24h |  | 1,200 | 800 |  |
| 22 | 8 | Fin Proceso de Pruebas | milestone | 0d | 2015-09-14 | 2015-09-14 | 21 |  |  | 2015-08-13 | 2015-08-13 | 0d | 2015-08-13 | 2015-08-13 | 0d |  | must finish on 2015-09-14 |  |  |  |  |  |  |  |
