# Develop CRM Software 30

Schedule from MS Project, 2012-05-02 to 2012-08-13, status date 2012-05-01, costs in $, A marks actual dates.
Project 2010 Advanced
msProjectExperts
Use this project to demonstrate the advanced use of standard fields in Microsoft Project 2010.

## Calendars

- Proyectos CRM: Mon-Fri 08:00-12:00, 13:00-17:00; Sat-Sun off. Exceptions (off unless hours are given): 2012-05-30 (Memorial Day), 2012-07-04 (Independence Day).

## Resources

| Resource | Group | Rate | Notes |
| --- | --- | --- | --- |
| Audrey Kehrli | Dev | 50 | August 15-19, 2005 - Vacation |
| Jeff Holly | Dev | 50 |  |
| Carmen Kamper | PMO | 50 |  |
| Bob Jared | Test | 50 |  |
| Software Tester | Test | 50 |  |

## Schedule

| ID | WBS | Task | Type | Duration | Start | Finish | Predecessors | Complete | Remaining | Baseline start | Baseline finish | Baseline duration | Baseline 1 start | Baseline 1 finish | Total slack | Free slack | Constraint | Deadline | Resources | Work | Actual work | Cost | Baseline cost | Actual cost |
| --- | --- | --- | --- | --- | --- | --- | --- | --- | --- | --- | --- | --- | --- | --- | --- | --- | --- | --- | --- | --- | --- | --- | --- | --- |
| 1 | 1 | **Analysis/Software Requirements** |  | 16d | 2012-05-02 A | 2012-05-23 A |  | 100% |  | 2012-05-02 | 2012-05-23 | 16d | 2012-05-02 | 2012-05-23 |  |  |  |  |  | 66h | 66h | 3,300 | 3,300 | 3,300 |
| 2 | 1.1 | Conduct needs analysis |  | 4d | 2012-05-02 A | 2012-05-07 A |  | 100% |  | 2012-05-02 | 2012-05-07 | 4d | 2012-05-02 | 2012-05-07 |  |  | finish no later than 2012-05-06 |  | Carmen Kamper [75%] | 24h | 24h | 1,200 | 1,200 | 1,200 |
| 3 | 1.2 | Draft software specifications |  | 6d | 2012-05-08 A | 2012-05-15 A | 2 | 100% |  | 2012-05-08 | 2012-05-15 | 6d | 2012-05-08 | 2012-05-15 |  |  |  |  | Audrey Kehrli [62.5%] | 24h | 24h | 1,200 | 1,200 | 1,200 |
| 4 | 1.3 | Develop budget |  | 1.8d | 2012-05-16 A | 2012-05-17 A | 3 | 100% |  | 2012-05-16 | 2012-05-17 | 1.8d | 2012-05-16 | 2012-05-17 |  |  |  |  | Carmen Kamper [75%] | 10h | 10h | 500 | 500 | 500 |
| 5 | 1.4 | Develop delivery timeline |  | 3d | 2012-05-18 A | 2012-05-23 A | 4 | 100% |  | 2012-05-18 | 2012-05-23 | 3d | 2012-05-18 | 2012-05-23 |  |  |  |  | Audrey Kehrli [50%] | 8h | 8h | 400 | 400 | 400 |
| 6 | 2 | Analysis complete | milestone | 0d | 2012-05-23 A | 2012-05-23 A | 5 | 100% |  | 2012-05-23 | 2012-05-23 | 0d | 2012-05-23 | 2012-05-23 |  |  |  | 2012-05-23 |  |  |  |  |  |  |
| 7 | 3 | **Design** |  | 12d | 2012-05-24 A | 2012-06-11 A |  | 100% |  | 2012-05-24 | 2012-06-11 | 12d | 2012-05-24 | 2012-06-11 |  |  |  |  |  | 69h | 69h | 3,650 | 3,650 | 3,650 |
| 8 | 3.1 | Develop functional specifications |  | 9d | 2012-05-24 A | 2012-06-07 A | 6 | 100% |  | 2012-05-24 | 2012-06-07 | 9d | 2012-05-24 | 2012-06-07 |  |  | start no earlier than 2012-05-16 |  | Jeff Holly [62.5%] | 37h | 37h | 1,850 | 1,850 | 1,850 |
| 9 | 3.2 | Develop prototype based on functional specifications |  | 3d | 2012-06-07 A | 2012-06-11 A | 8 | 100% |  | 2012-06-07 | 2012-06-11 | 3d | 2012-06-07 | 2012-06-11 |  |  |  |  | Jeff Holly | 32h | 32h | 1,800 | 1,800 | 1,800 |
| 10 | 4 | Design complete | milestone | 0d | 2012-06-09 A | 2012-06-09 A | 9 | 100% |  | 2012-06-09 | 2012-06-09 | 0d | 2012-06-09 | 2012-06-09 |  |  |  | 2012-06-09 |  |  |  |  |  |  |
| 11 | 5 | **Development** |  | 28d | 2012-06-10 A | 2012-07-19 |  | 17% | 23.22d | 2012-06-10 | 2012-07-16 | 25d | 2012-06-10 | 2012-07-16 | 17d |  |  |  |  | 259.5h | 32h | 12,975 | 12,400 | 1,600 |
| 12 | 5.1 | Identify design parameters |  | 1d | 2012-06-10 A | 2012-06-11 A | 10 | 100% |  | 2012-06-10 | 2012-06-11 | 1d | 2012-06-10 | 2012-06-11 |  |  |  |  | Jeff Holly [50%] | 4h | 4h | 200 | 200 | 200 |
| 13 | 5.2 | Develop code |  | 21d | 2012-06-13 A | 2012-07-12 | 12 | 14% | 18d | 2012-06-13 | 2012-07-12 | 21d | 2012-06-13 | 2012-07-12 | 22d | 0d |  |  | Jeff Holly | 156h | 12h | 7,800 | 7,800 | 600 |
| 14 | 5.3 | Developer testing (primary debugging) |  | 24.88d | 2012-06-14 A | 2012-07-19 | 13SS+1d | 16% | 20.88d | 2012-06-14 | 2012-07-16 | 22d | 2012-06-14 | 2012-07-16 | 0d |  | finish no earlier than 2012-07-19 |  | Software Tester [50%] | 99.5h | 16h | 4,975 | 4,400 | 800 |
| 15 | 6 | Development complete | milestone | 0d | 2012-07-19 | 2012-07-19 | 14 |  |  | 2012-07-16 | 2012-07-16 | 0d | 2012-07-16 | 2012-07-16 | 0d |  |  | 2012-07-20 |  |  |  |  |  |  |
| 16 | 7 | **Testing** |  | 17d | 2012-07-20 | 2012-08-13 |  |  |  | 2012-07-17 | 2012-08-08 | 16.88d | 2012-07-17 | 2012-08-08 | 0d |  |  |  |  | 116h |  | 5,800 | 5,800 |  |
| 17 | 7.1 | Review modular code |  | 5d | 2012-07-20 | 2012-07-26 | 15 |  |  | 2012-07-17 | 2012-07-23 | 5d | 2012-07-17 | 2012-07-23 | 0d |  | start no earlier than 2012-07-11 |  | Bob Jared | 40h |  | 2,000 | 2,000 |  |
| 18 | 7.2 | Test component modules to product specifications |  | 2d | 2012-07-27 | 2012-07-30 | 17 |  |  | 2012-07-24 | 2012-07-25 | 2d | 2012-07-24 | 2012-07-25 | 0d |  |  |  | Software Tester | 16h |  | 800 | 800 |  |
| 19 | 7.3 | Identify anomalies to product specifications |  | 3d | 2012-07-31 | 2012-08-02 | 18 |  |  | 2012-07-26 | 2012-07-30 | 3d | 2012-07-26 | 2012-07-30 | 0d |  |  |  | Software Tester | 24h |  | 1,200 | 1,200 |  |
| 20 | 7.4 | Modify code |  | 5d | 2012-08-03 | 2012-08-09 | 19 |  |  | 2012-07-31 | 2012-08-06 | 5d | 2012-07-31 | 2012-08-06 | 0d |  |  |  | Jeff Holly [50%] | 20h |  | 1,000 | 1,000 |  |
| 21 | 7.5 | Re-test modified code |  | 2d | 2012-08-10 | 2012-08-13 | 20 |  |  | 2012-08-07 | 2012-08-08 | 2d | 2012-08-07 | 2012-08-08 | 0d |  |  |  | Bob Jared | 16h |  | 800 | 800 |  |
| 22 | 8 | Testing Complete | milestone | 0d | 2012-08-13 | 2012-08-13 | 21 |  |  | 2012-08-12 | 2012-08-12 | 0d | 2012-08-12 | 2012-08-12 | 0d |  |  |  |  |  |  |  |  |  |

Notes:
- 2: ·FNLT 5/6/11 - Contraul finish date for task.
- 3: ·Audrey Kehrli pulled off this project 50% of the time to assist with higher priority project.
- 5: ·Audrey Kehrli pulled off this project 50% of the time to assist with higher priority project.
- 8: ·SNET 5/16/11 - Resource availability issue. / ·Jeff Holly reported that drafting the functional specifications took longer than the time budgeted as the software specifications were incomplete.
- 13: ·Jeff Holly is unavailable to work full-time on any project work beginning 6/13/11 due to half-time educational leave approved by CIO.
- 17: ·SNET 7/11/11 - Resource availability issue.
- 22: ·FNLT 8/12/11 - Contractual finish date for entire project.
